# My Shed1c

How a schedule from MS Project changed from version to version. A marks actual dates.

## Version 1 (saved 2005-06-14, file My Shed1c.mpp)

| ID | WBS | Task | Duration | Start | Finish | Total float |
| --- | --- | --- | --- | --- | --- | --- |
| 1 |  | Order kit & schedule delivery | 1d? | 2005-07-07 | 2005-07-07 | 0d |
| 2 | 2 | **Preparation** | 1d? | 2005-07-07 | 2005-07-07 | 0d |
| 3 |  | Site preparation | 1d? | 2005-07-07 | 2005-07-07 | 0d |
| 4 |  | Pour the foundation | 1d? | 2005-07-07 | 2005-07-07 | 0d |
| 5 |  | Receive the delivery | 1d? | 2005-07-07 | 2005-07-07 | 0d |
| 6 |  | Delivery milestone | 1d? | 2005-07-07 | 2005-07-07 | 0d |
| 7 | 5 | **Assembly** | 1d? | 2005-07-07 | 2005-07-07 | 0d |
| 8 |  | Assemble kit | 1d? | 2005-07-07 | 2005-07-07 | 0d |
| 9 |  | Stain the shed | 1d? | 2005-07-07 | 2005-07-07 | 0d |
| 10 |  | Plant landscaping | 1d? | 2005-07-07 | 2005-07-07 | 0d |
| 11 |  | Fill the shed | 1d? | 2005-07-07 | 2005-07-07 | 0d |

## Version 2 (saved 2005-06-14, file My Shed1d.mpp)

Last finish 2005-07-07 → 2005-07-15 (+8d).

Changed:

| ID | Task | Start | Finish | Duration | Total float | Other |
| --- | --- | --- | --- | --- | --- | --- |
| 1 | Order kit & schedule delivery |  |  | 1d? → 1d | 0d → 6d |  |
| 2 | **Preparation** |  | 2005-07-07 → 2005-07-15 (+8d) | 1d? → 7d |  |  |
| 3 | Site preparation |  | 2005-07-07 → 2005-07-08 (+1d) | 1d? → 2d | 0d → 5d |  |
| 4 | Pour the foundation | 2005-07-07 → 2005-07-15 (+8d) | 2005-07-07 → 2005-07-15 (+8d) | 1d? → 1d |  | constraint none → start no earlier than 2005-07-15 |
| 5 | Receive the delivery |  |  | 1d? → 1d | 0d → 6d |  |
| 6 | Delivery milestone |  |  | 1d? → 0d | 0d → 7d |  |
| 7 | **Assembly** |  | 2005-07-07 → 2005-07-08 (+1d) | 1d? → 2d | 0d → 5d |  |
| 8 | Assemble kit |  | 2005-07-07 → 2005-07-08 (+1d) | 1d? → 2d | 0d → 5d |  |
| 9 | Stain the shed |  |  | 1d? → 1d | 0d → 6d |  |
| 10 | Plant landscaping |  |  | 1d? → 1d | 0d → 6d |  |
| 11 | Fill the shed |  |  | 1d? → 1d | 0d → 6d |  |

## Version 3 (saved 2005-06-14, file My Shed1e.mpp)

Last finish 2005-07-15 → 2005-07-29 (+14d).

Changed:

| ID | Task | Start | Finish | Duration | Total float | Predecessors |
| --- | --- | --- | --- | --- | --- | --- |
| 2 | **Preparation** |  |  |  |  | none → 1SS |
| 4 | Pour the foundation |  |  |  |  | none → 3 |
| 5 | Receive the delivery | 2005-07-07 → 2005-07-21 (+14d) | 2005-07-07 → 2005-07-21 (+14d) |  | 6d → 0d | none → 2FS+3d |
| 6 | Delivery milestone | 2005-07-07 → 2005-07-21 (+14d) | 2005-07-07 → 2005-07-21 (+14d) |  | 7d → 6d | none → 5 |
| 7 | **Assembly** | 2005-07-07 → 2005-07-21 (+14d) | 2005-07-08 → 2005-07-28 (+20d) | 2d → 6d | 5d → 0d | none → 5SS |
| 8 | Assemble kit | 2005-07-07 → 2005-07-21 (+14d) | 2005-07-08 → 2005-07-22 (+14d) |  | 5d → 0d |  |
| 9 | Stain the shed | 2005-07-07 → 2005-07-28 (+21d) | 2005-07-07 → 2005-07-28 (+21d) |  | 6d → 0d | none → 8FS+3d |
| 10 | Plant landscaping | 2005-07-07 → 2005-07-28 (+21d) | 2005-07-07 → 2005-07-28 (+21d) |  | 6d → 0d | none → 9SS |
| 11 | Fill the shed | 2005-07-07 → 2005-07-29 (+22d) | 2005-07-07 → 2005-07-29 (+22d) |  | 6d → 0d | none → 7 |

## Version 4 (saved 2005-06-14, file My Shed1g.mpp)

Last finish stays 2005-07-29.

Changed:

| ID | Task | Total float | Other |
| --- | --- | --- | --- |
| 1 | Order kit & schedule delivery | 6d → 4d | resources none → John Doe |
| 3 | Site preparation |  | resources none → Betty Doe; Frank Doe; John Doe |
| 4 | Pour the foundation |  | resources none → John Doe; Andy Handy |
| 5 | Receive the delivery |  | resources none → John Doe |
| 8 | Assemble kit |  | resources none → John Doe; Andy Handy |
| 9 | Stain the shed |  | resources none → Frank Doe; Betty Doe |
| 10 | Plant landscaping |  | resources none → Betty Doe |
| 11 | Fill the shed |  | resources none → John Doe; Frank Doe |

## Version 5 (saved 2005-06-14, file My Shed1h.mpp)

Last finish stays 2005-07-29.

Changed:

| ID | Task | Other |
| --- | --- | --- |
| 1 | Order kit & schedule delivery | resources John Doe → John Doe [25%] |
| 3 | Site preparation | resources Betty Doe; Frank Doe; John Doe → Betty Doe [75%]; Frank Doe [75%]; John Doe [75%] |
| 4 | Pour the foundation | resources John Doe; Andy Handy → John Doe [62.5%]; Andy Handy [62.5%] |
| 5 | Receive the delivery | resources John Doe → John Doe [25%] |
| 8 | Assemble kit | resources John Doe; Andy Handy → John Doe [62.5%]; Andy Handy [62.5%] |
| 9 | Stain the shed | resources Frank Doe; Betty Doe → Frank Doe [25%]; Betty Doe [25%] |
| 10 | Plant landscaping | resources Betty Doe → Betty Doe [50%] |
| 11 | Fill the shed | resources John Doe; Frank Doe → John Doe [62.5%]; Frank Doe [62.5%] |

## Version 6 (saved 2005-06-14, file My Shed2a.mpp)

Last finish stays 2005-07-29.

Changed:

| ID | Task | Other |
| --- | --- | --- |
| 1 | Order kit & schedule delivery | baseline start none → 2005-07-07; baseline finish none → 2005-07-07 |
| 2 | **Preparation** | baseline start none → 2005-07-07; baseline finish none → 2005-07-15 |
| 3 | Site preparation | baseline start none → 2005-07-07; baseline finish none → 2005-07-08 |
| 4 | Pour the foundation | baseline start none → 2005-07-15; baseline finish none → 2005-07-15 |
| 5 | Receive the delivery | baseline start none → 2005-07-21; baseline finish none → 2005-07-21 |
| 6 | Delivery milestone | baseline start none → 2005-07-21; baseline finish none → 2005-07-21 |
| 7 | **Assembly** | baseline start none → 2005-07-21; baseline finish none → 2005-07-28 |
| 8 | Assemble kit | baseline start none → 2005-07-21; baseline finish none → 2005-07-22 |
| 9 | Stain the shed | baseline start none → 2005-07-28; baseline finish none → 2005-07-28 |
| 10 | Plant landscaping | baseline start none → 2005-07-28; baseline finish none → 2005-07-28 |
| 11 | Fill the shed | baseline start none → 2005-07-29; baseline finish none → 2005-07-29 |

## Version 7 (saved 2005-06-14, file My Shed2b.mpp)

Last finish 2005-07-29 → 2005-08-05 (+7d). Complete tasks 0 → 5.

Changed:

| ID | Task | Start | Finish | Duration | Complete | Total float | Predecessors | Other |
| --- | --- | --- | --- | --- | --- | --- | --- | --- |
| 1 | Order kit & schedule delivery | 2005-07-07 A | 2005-07-07 A |  | 0% → 100% | 4d → none |  |  |
| 2 | **Preparation** | 2005-07-07 A | 2005-07-15 A |  | 0% → 100% | 0d → none |  |  |
| 3 | Site preparation | 2005-07-07 A | 2005-07-08 A |  | 0% → 100% | 4d → none |  | resources Betty Doe [75%]; Frank Doe [75%]; John Doe [75%] → Betty Doe [50%]; Frank Doe [50%]; John Doe [50%] |
| 4 | Pour the foundation | 2005-07-15 A | 2005-07-15 A |  | 0% → 100% | 0d → none |  |  |
| 5 | Receive the delivery | 2005-07-21 A | 2005-07-21 A |  | 0% → 100% | 0d → none |  | resources John Doe [25%] → John Doe [12.5%] |
| 6 | Delivery milestone | 2005-07-21 A | 2005-07-21 A |  | 0% → 100% | 6d → none |  |  |
| 7 | **Assembly** | 2005-07-21 → 2005-07-22 (+1d) | 2005-07-28 → 2005-08-04 (+7d) | 6d → 10d |  |  |  |  |
| 8 | Assemble kit | 2005-07-21 → 2005-07-22 (+1d) | 2005-07-22 → 2005-07-28 (+6d) | 2d → 5d |  |  |  | constraint none → start no earlier than 2005-07-22; resources John Doe [62.5%]; Andy Handy [62.5%] → John Doe [25%]; Andy Handy [25%] |
| 9 | Stain the shed | 2005-07-28 → 2005-08-04 (+7d) | 2005-07-28 → 2005-08-04 (+7d) |  |  |  | 8FS+3d → 8FS+4d |  |
| 10 | Plant landscaping | 2005-07-28 → 2005-08-04 (+7d) | 2005-07-28 → 2005-08-04 (+7d) |  |  |  |  |  |
| 11 | Fill the shed | 2005-07-29 → 2005-08-05 (+7d) | 2005-07-29 → 2005-08-05 (+7d) |  |  |  |  |  |
